# WBS 1409r1

Schedule from MS Project, 2003-11-03 to 2004-07-28.
PPPL

## Calendars

- Standard: Mon-Fri 08:00-12:00, 13:00-17:00; Sat-Sun off.

## Schedule

| ID | Task | Type | Duration | Start | Finish | Predecessors | Total slack | Free slack | Constraint |
| --- | --- | --- | --- | --- | --- | --- | --- | --- | --- |
| 1 | Oversight/Supervision (1409-029) |  | 120d | 2003-11-03 | 2004-04-16 |  | 73d | 62d | start no earlier than 2003-11-03 |
| 2 | Install Electrical (1409-026) |  | 56d | 2003-12-15 | 2004-03-01 |  | 97d | 86d | start no earlier than 2003-12-15 |
| 3 | Generate I2t Requirements |  | 5d | 2004-03-08 | 2004-03-12 |  | 58d | 0d | finish no earlier than 2004-03-12 |
| 4 | Design I2t Protection |  | 15d | 2004-03-15 | 2004-04-02 | 3 | 58d | 0d |  |
| 5 | Fabricate I2t Cards |  | 15d | 2004-04-22 | 2004-05-12 | 4 | 45d | 34d | start no earlier than 2004-04-22 |
| 6 | Define N2 Ejection Scheme |  | 2d | 2004-02-23 | 2004-02-24 |  | 73d | 0d | start no earlier than 2004-02-23 |
| 7 | Plan/Procure N2 Ejection System |  | 14d | 2004-02-25 | 2004-03-15 | 6 | 73d | 52d |  |
| 8 | Install N2 Ejection Scheme |  | 14d | 2004-05-27 | 2004-06-15 | 7 | 21d | 10d | start no earlier than 2004-05-27 |
| 9 | Cryo Line Installation (1409-027) |  | 15d | 2004-03-08 | 2004-03-26 |  | 78d | 67d | start no earlier than 2004-03-08 |
| 10 | ES&H Peer Review | milestone | 0d | 2004-04-05 | 2004-04-05 |  | 73d | 62d | start no earlier than 2004-04-05 |
| 11 | DELETEDPeer Review for FacilityDELETED | milestone | 0d | 2004-03-16 | 2004-03-16 | 3, 6 | 97d |  | start no earlier than 2004-03-16 |
| 12 | Design Controls Modifications |  | 20d | 2004-04-08 | 2004-05-05 |  | 38d | 0d | finish no earlier than 2004-05-05 |
| 13 | Install Controls Modifications |  | 12d | 2004-05-07 | 2004-05-24 | 12 | 37d | 26d | finish no earlier than 2004-05-24 |
| 14 | Controls Peer Review | milestone | 0d | 2004-05-12 | 2004-05-12 | 4, 12 | 46d | 0d | start no earlier than 2004-05-12 |
| 15 | Final Design Review | milestone | 0d | 2004-05-12 | 2004-05-12 | 4, 7, 10, 14 | 46d | 25d |  |
| 16 | System Testing (1409-028) |  | 10d | 2004-06-16 | 2004-06-29 | 2, 15, 9, 8, 5, 13 | 21d | 0d |  |
| 17 | Declare Facility (simply cooled) Available | milestone | 0d | 2004-06-29 | 2004-06-29 | 1, 16 | 21d |  |  |
| 18 | Design Closed Loop LN2 System |  | 27d? | 2004-04-07 | 2004-05-13 |  | 0d |  | finish no earlier than 2004-05-13 |
| 19 | Peer Review Closed Loop LN2 System | milestone | 0d | 2004-05-13 | 2004-05-13 | 18 | 54d |  |  |
| 20 | Procure Mat'ls/Pump for Closed Loop LN2 System |  | 47d | 2004-05-14 | 2004-07-19 | 18 | 0d |  |  |
| 21 | Fab/Install Closed Loop LN2 System |  | 15d | 2004-05-14 | 2004-06-03 | 18 | 32d |  |  |
| 22 | Test Closed Loop Cooling |  | 7d | 2004-07-20 | 2004-07-28 | 21, 20 | 0d |  |  |
| 23 | Declare Closed Loop Facility Available | milestone | 0d | 2004-07-28 | 2004-07-28 | 22, 16 | 0d |  |  |
